# Projeto 2 VH

Schedule from MS Project, 2016-08-03 to 2018-02-28.

## Calendars

- Padrão: Mon-Fri 09:00-12:00, 13:00-18:00; Sat-Sun off. Exceptions (off unless hours are given): 2016-09-07, 2016-10-12, 2016-11-02, 2016-11-15.

## Schedule

| ID | WBS | Task | Duration | Start | Finish | Predecessors | Baseline start | Baseline finish | Baseline duration | Total slack | Free slack |
| --- | --- | --- | --- | --- | --- | --- | --- | --- | --- | --- | --- |
| 1 | 1 | **TRF - 1 VARA HORIZONTAL** | 407d | 2016-08-03 | 2018-02-28 |  | 2016-08-03 | 2018-09-13 | 548d |  |  |
| 2 | 1.1 | **ADMINISTRAÇÃO LOCAL** | 90d | 2016-08-03 | 2016-12-12 |  | 2016-08-03 | 2018-09-13 | 548d | -3.12d | 0d |
| 3 | 1.1.1 | MÃO DE OBRA INDIRETA | 30d | 2016-08-03 | 2016-09-14 |  | 2016-08-03 | 2018-09-13 | 548d | 0d |  |
| 4 | 1.1.2 | CONSUMOS | 30d | 2016-08-03 | 2016-09-14 | 3SS | 2016-08-03 | 2018-09-13 | 548d | 396d |  |
| 5 | 1.1.3 | EQUIPAMENTOS DE PROTEÇÃO COLETIVA | 30d | 2016-10-28 | 2016-12-12 | 30SS | 2016-08-03 | 2016-08-03 | 1d | 336d |  |
| 6 | 1.2 | **INSTALAÇÕES PROVISÓRIAS, ANDAIMES, TRANSPORTE VERTICAL** | 359d | 2016-08-25 | 2018-01-15 |  | 2016-08-25 | 2016-09-21 | 19d | 32d |  |
| 7 | 1.2.1 | TAPUME DE CHAPA DE MADEIRA COMPENSADA | 5d | 2016-08-25 | 2016-08-31 | 19SS+1d | 2016-08-25 | 2016-08-31 | 5d | 299d | 0d |
| 8 | 1.2.2 | BARRACÃO PARA ESCRITÓRIOS (CONSIDERANDO 2 DE 4,00 X 4,00 M) | 10d | 2016-08-25 | 2016-09-08 | 7SS | 2016-08-25 | 2016-09-07 | 10d | 406d |  |
| 9 | 1.2.3 | BARRACÃO PARA ALMOXARIFADO | 10d | 2016-08-25 | 2016-09-08 | 7SS | 2016-08-25 | 2016-09-07 | 10d | 406d |  |
| 10 | 1.2.4 | BARRACÃO DE SANITÁRIO, VESTIÁRIO E REFEITÓRIO | 10d | 2016-08-25 | 2016-09-08 | 7SS | 2016-08-25 | 2016-09-07 | 10d | 324d | 0d |
| 11 | 1.2.5 | INSTALAÇÕES PROVISÓRIAS DE ÁGUA, ESGOTO E ENERGIA | 3d | 2016-08-25 | 2016-08-29 | 7SS | 2016-08-25 | 2016-08-29 | 3d | 413d |  |
| 12 | 1.2.6 | PLACA DE OBRA EM CHAPA DE AÇO GALVANIZADO | 2d | 2016-08-25 | 2016-08-26 | 7SS | 2016-08-25 | 2016-08-26 | 2d | 414d |  |
| 13 | 1.2.7 | LOCAÇÃO DE OBRA (GABARITO) | 5d | 2016-09-16 | 2016-09-22 | 7SS+15d | 2016-09-15 | 2016-09-21 | 5d | 371d |  |
| 14 | 1.2.8 | LOCAÇÃO MENSAL DE ANDAIME METÁLICO TIPO FACHADEIRO, INCLUSIVE MONTAGEM | 90d | 2017-09-08 | 2018-01-11 | 54SS | 2016-08-25 | 2016-08-25 | 1d | 36d | 0d |
| 15 | 1.2.9 | PLATAFORMA DE MADEIRA PARA ANDAIME | 90d | 2017-09-08 | 2018-01-11 | 14SS | 2016-08-25 | 2016-08-25 | 1d | 36d |  |
| 16 | 1.2.10 | FORNECIMENTO E LOCAÇÃO DE EQUIPAMENTOS (BETONEIRA, MAKITA, SERRA DE BANCA E VIBRADOR DE IMERSÃO) | 90d | 2016-08-29 | 2017-01-05 | 10SS+2d | 2016-08-29 | 2016-08-29 | 1d | 299d |  |
| 17 | 1.2.11 | DESCARGA E TRANSPORTE DE MATERIAIS ATÉ AS FRENTES DE SERVIÇO (ÁREA APROXIMADA DE 4.000 M2) | 320d | 2016-10-21 | 2018-01-15 | 29SS | 2016-08-25 | 2016-08-25 | 1d | 57d |  |
| 18 | 1.3 | **MOBILIZAÇÃO E DESMOBILIZAÇÃO DE OBRA** | 367.88d | 2016-08-24 | 2018-01-25 |  | 2016-08-24 | 2018-09-13 | 532.88d | -3.12d | 0d |
| 19 | 1.3.1 | MOBILIZAÇÃO E DESMOBILIZAÇÃO DE OBRA EXECUTADAS EM CENTROS URBANOS OU PRÓXIMOS DE CENTROS URBANOS | 55.88d | 2016-08-24 | 2018-01-25 | 3SS+15d | 2016-08-24 | 2018-09-13 | 532.88d | 0d |  |
| 20 | 1.4 | **SERVIÇOS TÉCNICOS E ESPECÍFICOS** | 360.12d | 2016-08-03 | 2017-12-26 |  | 2016-08-10 | 2016-08-10 | 1d | 46.88d |  |
| 21 | 1.4.1 | AS BUILT DE PROJETOS COM ÁREA ATÉ 10.000 M2 | 30d | 2016-08-03 | 2016-09-14 |  | 2016-08-10 | 2016-08-10 | 1d | 402d |  |
| 22 | 1.4.2 | ENSAIO DE RESISTÊNCIA A COMPRESSÃO SIMPLES - CONCRETO | 60d | 2016-11-01 | 2017-01-25 | 28SS+1d | 2016-08-10 | 2016-08-10 | 1d | 285d |  |
| 23 | 1.4.3 | ENSAIO DE ESTANQUEIDADE DE INSTALAÇÕES HIDRÁULICAS (ÁGUA FRIA, INCÊNDIO E REDE DE DISTRIBUIÇÃO DE ÁGUA POTÁVEL) | 23.12d | 2017-11-23 | 2017-12-26 | 85SS | 2016-08-10 | 2016-08-10 | 1d | 48.88d |  |
| 24 | 1.4.4 | PCMAT (NR-18) E PCSMO (NR-7) | 7d | 2016-08-10 | 2016-08-18 | 3SS+5d | 2016-08-10 | 2016-08-10 | 1d | 420d |  |
| 25 | 1.5 | FUNDAÇÃO | 30d | 2016-09-08 | 2016-10-20 | 19SS+10d |  |  |  | -3.12d | 0d |

| ID | WBS | Task | Duration | Start | Finish | Predecessors | Baseline start | Baseline finish | Baseline duration | Total slack | Free slack |
| --- | --- | --- | --- | --- | --- | --- | --- | --- | --- | --- | --- |
| 26 | 1.6 | **ESTRUTURA** | 288d | 2016-10-21 | 2017-11-30 |  | 2016-08-03 | 2017-01-09 | 110d | -3.12d | 0d |
| 27 | 1.6.1 | **ESTRUTURA DE CONCRETO** | 72d | 2016-10-21 | 2017-02-01 |  | 2016-10-03 | 2017-01-09 | 68d | -3.12d | 0d |
| 28 | 1.6.1.1 | FORNECIMENTO E APLICAÇÃO DE CONCRETO USINADO BOMBEADO FCK=25MPA, INCLUSIVE LANCAMENTO E ADENSAMENTO | 66d | 2016-10-31 | 2017-02-01 | 31SS | 2016-10-05 | 2017-01-09 | 66d | 0d |  |
| 29 | 1.6.1.2 | FORNECIMENTO, CORTE, DOBRA E COLOCAÇÃO DE ARMAÇÃO EM AÇO CA-50 | 66d | 2016-10-21 | 2017-01-24 | 25 | 2016-10-03 | 2017-01-05 | 66d | -3.12d | 0d |
| 30 | 1.6.1.3 | FORNECIMENTO E MONTAGEM DE FORMA PARA ESTRUTURAS DE CONCRETO (PILAR, VIGA E LAJE) - FABRICAÇÃO, MONTAGEM E DESMONTAGEM INCLUSIVE ESCORAMENTO | 66d | 2016-10-28 | 2017-01-31 | 29SS+5d | 2016-10-04 | 2017-01-06 | 66d | -3.12d | 0d |
| 31 | 1.6.1.4 | FORNECIMENTO E EXECUÇÃO DE CIMBRAMENTO/ESCORAMENTO, PARA LAJES, INCLUSIVE CARGA E DESCARGA | 66d | 2016-10-31 | 2017-02-01 | 30SS+1d | 2016-10-04 | 2017-01-06 | 66d | -3.12d | 0d |
| 32 | 1.6.2 | **ESTRUTURA METÁLICA** | 45d | 2017-09-29 | 2017-11-30 |  | 2016-08-03 | 2016-08-03 | 1d | 64d |  |
| 33 | 1.6.2.1 | FORNECIMENTO E MONTAGEM DE PERFIS METÁLICOS EM AÇO LAMINADO TIPO "I", PINTADO NA COR CINZA | 45d | 2017-09-29 | 2017-11-30 | 54SS+15d | 2016-08-03 | 2016-08-03 | 1d | 64d |  |
| 34 | 1.7 | **ALVENARIA, DIVISÓRIAS, VERGAS E CONTRA-VERGAS** | 150d | 2017-02-02 | 2017-08-30 |  | 2016-08-03 | 2016-08-03 | 1d | -3.12d | 0d |
| 35 | 1.7.1 | ALVENARIAS DE BLOCOS DE CONCRETO, VERGAS E CONTRAVERGAS | 120d | 2017-02-02 | 2017-07-19 | 28 | 2016-08-03 | 2016-08-03 | 1d | -3.12d | 0d |
| 36 | 1.7.2 | PAREDES DE GESSO ACARTONADO | 30d | 2017-07-20 | 2017-08-30 | 35 | 2016-08-03 | 2016-08-03 | 1d | 130d |  |
| 37 | 1.8 | **ESQUADRIAS E FERRAGENS** | 160d | 2017-07-20 | 2018-02-28 |  | 2016-08-03 | 2016-08-03 | 1d | 0d |  |
| 38 | 1.8.1 | ESQUADRIAS DE MADEIRA - PORTAS | 60d | 2017-07-20 | 2017-10-11 | 35 | 2016-08-03 | 2016-08-03 | 1d | 95d | 0d |
| 39 | 1.8.2 | ESQUADRIAS DE ALUMÍNIO - PORTAS | 15d | 2017-07-27 | 2017-08-16 | 35FS+5d | 2016-08-03 | 2016-08-03 | 1d | 0d |  |
| 40 | 1.8.3 | ESQUADRIAS DE ALUMÍNIO - JANELAS | 60d | 2017-08-18 | 2017-11-09 | 39FS+1d | 2016-08-03 | 2016-08-03 | 1d | 0d |  |
| 41 | 1.8.4 | ESQUADRIAS DE PELE DE VIDRO E ALUMÍNIO - JANELAS | 63d | 2017-12-04 | 2018-02-28 | 54FS+1d | 2016-08-03 | 2016-08-03 | 1d | 0d |  |
| 42 | 1.8.5 | ESQUADRIAS METÁLICAS - PORTAS | 30d | 2017-11-13 | 2017-12-22 | 40FS+1d | 2016-08-03 | 2016-08-03 | 1d | 48d |  |
| 43 | 1.8.6 | FERRAGENS | 60d | 2017-07-27 | 2017-10-18 | 38SS+5d | 2016-08-03 | 2016-08-03 | 1d | 95d |  |
| 44 | 1.9 | **VIDROS E ESPELHOS** | 60d | 2017-12-04 | 2018-02-23 |  | 2016-08-03 | 2016-08-03 | 1d | 3d |  |
| 45 | 1.9.1 | VIDROS LISOS E TEMPERADOS | 60d | 2017-12-04 | 2018-02-23 | 54FS+1d | 2016-08-03 | 2016-08-03 | 1d | 3d | 0d |
| 46 | 1.9.2 | ESPELHOS | 30d | 2017-12-04 | 2018-01-12 | 45SS | 2016-08-03 | 2016-08-03 | 1d | 35d |  |
| 47 | 1.10 | **COBERTURA** | 70d | 2017-08-10 | 2017-11-15 |  | 2016-08-03 | 2016-08-03 | 1d | 75d |  |
| 48 | 1.10.1 | COBERTURA COM TELHAS SANDUÍCHE | 60d | 2017-08-10 | 2017-11-01 | 35FS+15d | 2016-08-03 | 2016-08-03 | 1d | 75d | 0d |
| 49 | 1.10.2 | RUFOS, CALHAS E CHAPINS | 10d | 2017-11-02 | 2017-11-15 | 48 | 2016-08-03 | 2016-08-03 | 1d | 75d |  |
| 50 | 1.11 | IMPERMEABILIZAÇÃO E ISOLAMENTO TÉRMICO | 90d | 2017-09-11 | 2018-01-12 | 61SS+5d | 2016-08-03 | 2016-08-03 | 1d | 33d |  |

| ID | WBS | Task | Duration | Start | Finish | Predecessors | Baseline start | Baseline finish | Baseline duration | Total slack | Free slack | Constraint |
| --- | --- | --- | --- | --- | --- | --- | --- | --- | --- | --- | --- | --- |
| 51 | 1.12 | **REVESTIMENTOS** | 85d | 2017-09-08 | 2018-01-04 |  | 2016-08-03 | 2016-08-03 | 1d | 0d |  |  |
| 52 | 1.12.1 | REVESTIMENTOS INTERNOS DE ARGAMASSA | 45d | 2017-09-29 | 2017-11-30 | 40SS+30d | 2016-08-03 | 2016-08-03 | 1d | 9d | 0d |  |
| 53 | 1.12.2 | REVESTIMENTOS DE PAREDES | 60d | 2017-10-13 | 2018-01-04 | 52SS+10d | 2016-08-03 | 2016-08-03 | 1d | 9d | 0d |  |
| 54 | 1.12.3 | REVESTIMENTOS EXTERNOS DE ARGAMASSA | 60d | 2017-09-08 | 2017-11-30 | 40SS+15d | 2016-08-03 | 2016-08-03 | 1d | 0d |  |  |
| 55 | 1.13 | FORROS | 35d | 2017-10-12 | 2017-11-29 | 118SS | 2016-08-03 | 2016-08-03 | 1d | -3.12d | 0d |  |
| 56 | 1.14 | **MARCENARIA E SERRALHERIA** | 55d | 2017-12-01 | 2018-02-15 |  |  |  |  | 9d |  |  |
| 57 | 1.14.1 | ARMÁRIO E PAINEL | 30d | 2018-01-05 | 2018-02-15 | 53 |  |  |  | 9d |  |  |
| 58 | 1.14.2 | SERRALHERIA | 30d | 2017-12-01 | 2018-01-11 | 54 |  |  |  | 34d |  |  |
| 59 | 1.15 | PINTURA | 68d | 2017-10-12 | 2018-01-15 | 55SS | 2016-08-03 | 2016-08-03 | 1d | -3.12d | 0d |  |
| 60 | 1.16 | **PISOS** | 71d | 2017-09-04 | 2017-12-11 |  | 2016-08-03 | 2016-08-03 | 1d | 33d |  |  |
| 61 | 1.16.1 | CONTRAPISO | 55d | 2017-09-04 | 2017-11-17 |  | 2016-08-03 | 2016-08-03 | 1d | 33d | 0d | start no earlier than 2017-09-04 |
| 62 | 1.16.2 | PISOS EM PORCELANATOS | 60d | 2017-09-11 | 2017-12-01 | 61SS+5d | 2016-08-03 | 2016-08-03 | 1d | 63d | 0d |  |
| 63 | 1.16.3 | PISOS DE GRANILITE | 60d | 2017-09-05 | 2017-11-27 | 61SS+1d | 2016-08-03 | 2016-08-03 | 1d | 57d | 0d |  |
| 64 | 1.16.4 | PISO ELEVADO | 30d | 2017-09-05 | 2017-10-16 | 63SS | 2016-08-03 | 2016-08-03 | 1d | 97d |  |  |
| 65 | 1.16.5 | PISO TÁTIL | 10d | 2017-11-28 | 2017-12-11 | 63 | 2016-08-03 | 2016-08-03 | 1d | 57d |  |  |
| 66 | 1.16.6 | **RODAPÉS, SOLEIRAS E PEITORIS** | 51d | 2017-09-18 | 2017-11-27 |  | 2016-08-03 | 2016-08-03 | 1d | 67d |  |  |
| 67 | 1.16.6.1 | RODAPÉS | 30d | 2017-10-17 | 2017-11-27 | 63SS+30d | 2016-08-03 | 2016-08-03 | 1d | 67d |  |  |
| 68 | 1.16.6.2 | SOLEIRAS E PEITORIS | 30d | 2017-09-18 | 2017-10-27 | 62SS+5d | 2016-08-03 | 2016-08-03 | 1d | 88d |  |  |
| 69 | 1.17 | **APARELHOS E METAIS** | 90d | 2017-03-16 | 2017-07-19 |  | 2016-08-03 | 2016-08-03 | 1d | 160d |  |  |
| 70 | 1.17.1 | VÁLVULAS | 15d | 2017-06-08 | 2017-06-28 | 73 | 2016-08-03 | 2016-08-03 | 1d | 175d |  |  |
| 71 | 1.17.2 | TORNEIRAS | 30d | 2017-06-08 | 2017-07-19 | 73 | 2016-08-03 | 2016-08-03 | 1d | 160d |  |  |
| 72 | 1.17.3 | BACIAS SANITÁRIAS E ASSENTOS | 60d | 2017-03-16 | 2017-06-07 | 81SS+30d | 2016-08-03 | 2016-08-03 | 1d | 190d |  |  |
| 73 | 1.17.4 | LAVATÓRIOS | 60d | 2017-03-16 | 2017-06-07 | 81SS+30d | 2016-08-03 | 2016-08-03 | 1d | 160d | 0d |  |
| 74 | 1.17.5 | DISPENSER | 15d | 2017-06-09 | 2017-06-29 | 73FS+1d | 2016-08-03 | 2016-08-03 | 1d | 174d |  |  |
| 75 | 1.17.6 | ALARME | 10d | 2017-06-09 | 2017-06-22 | 73FS+1d | 2016-08-03 | 2016-08-03 | 1d | 179d |  |  |
| 76 | 1.17.7 | BARRA DE APOIO | 10d | 2017-06-09 | 2017-06-22 | 73FS+1d | 2016-08-03 | 2016-08-03 | 1d | 179d |  |  |
| 77 | 1.17.8 | DIVERSOS | 15d | 2017-06-09 | 2017-06-29 | 73FS+1d | 2016-08-03 | 2016-08-03 | 1d | 174d |  |  |
| 78 | 1.18 | BANCADAS | 60d | 2017-03-16 | 2017-06-07 | 73SS | 2016-08-03 | 2016-08-03 | 1d | 190d |  |  |

| ID | WBS | Task | Duration | Start | Finish | Predecessors | Baseline start | Baseline finish | Baseline duration | Total slack | Free slack |
| --- | --- | --- | --- | --- | --- | --- | --- | --- | --- | --- | --- |
| 79 | 1.19 | **INSTALAÇÕES HIDRÁULICAS E SANITÁRIAS** | 225d | 2017-02-02 | 2017-12-13 |  | 2016-08-03 | 2016-08-03 | 1d | 46.88d |  |
| 80 | 1.19.1 | REGISTROS | 30d | 2017-04-27 | 2017-06-07 | 81SS+60d | 2016-08-03 | 2016-08-03 | 1d | 190d |  |
| 81 | 1.19.2 | TUBOS E CONEXÕES DE ÁGUA FRIA | 210d | 2017-02-02 | 2017-11-22 | 82SS | 2016-08-03 | 2016-08-03 | 1d | 46.88d | 0d |
| 82 | 1.19.3 | TUBOS E CONEXÕES DE ESGOTO SANITÁRIO | 210d | 2017-02-02 | 2017-11-22 | 28 | 2016-08-03 | 2016-08-03 | 1d | 46.88d | 0d |
| 83 | 1.19.4 | TUBOS E CONEXÕES DE ÁGUAS PLUVIAIS | 70d | 2017-02-23 | 2017-05-31 | 82SS+15d | 2016-08-03 | 2016-08-03 | 1d | 165d | 0d |
| 84 | 1.19.5 | CAIXAS SIFONADAS E RALOS | 30d | 2017-06-01 | 2017-07-12 | 83 | 2016-08-03 | 2016-08-03 | 1d | 165d |  |
| 85 | 1.19.6 | RESERVATÓRIOS | 15d | 2017-11-23 | 2017-12-13 | 81 | 2016-08-03 | 2016-08-03 | 1d | 46.88d | 0d |
| 86 | 1.20 | **INSTALAÇÕES DE PROTEÇÃO E COMBATE A INCÊNDIO** | 117d | 2017-03-16 | 2017-08-25 |  | 2016-08-03 | 2016-08-03 | 1d | 133d |  |
| 87 | 1.20.1 | TUBO DE AÇO GALVANIZADO | 70d | 2017-03-16 | 2017-06-21 | 81SS+30d | 2016-08-03 | 2016-08-03 | 1d | 133d | 0d |
| 88 | 1.20.2 | HIDRANTE | 30d | 2017-06-23 | 2017-08-03 | 87FS+1d | 2016-08-03 | 2016-08-03 | 1d | 149d |  |
| 89 | 1.20.3 | EXTINTORES | 30d | 2017-06-23 | 2017-08-03 | 87FS+1d | 2016-08-03 | 2016-08-03 | 1d | 133d | 0d |
| 90 | 1.20.4 | PLACAS | 15d | 2017-08-07 | 2017-08-25 | 89FS+1d | 2016-08-03 | 2016-08-03 | 1d | 133d |  |
| 91 | 1.20.5 | ALARME DE INCÊNDIO | 30d | 2017-06-23 | 2017-08-03 | 87FS+1d | 2016-08-03 | 2016-08-03 | 1d | 149d |  |
| 92 | 1.20.6 | ILUMINAÇÃO DE EMERGÊNCIA | 30d | 2017-06-23 | 2017-08-03 | 87FS+1d | 2016-08-03 | 2016-08-03 | 1d | 149d |  |
| 93 | 1.20.7 | BOMBA | 15d | 2017-06-23 | 2017-07-13 | 87FS+1d | 2016-08-03 | 2016-08-03 | 1d | 164d |  |
| 94 | 1.21 | **INSTALAÇÕES ELÉTRICAS** | 157d | 2017-07-20 | 2018-02-23 |  | 2016-08-03 | 2016-08-03 | 1d | -3.12d | 0d |
| 95 | 1.21.1 | ELETRODUTOS E CONEXÕES | 102d | 2017-07-20 | 2017-12-08 | 35 | 2016-08-03 | 2016-08-03 | 1d | -3.12d | 0d |
| 96 | 1.21.2 | FIOS E CABOS | 40d | 2017-12-11 | 2018-02-02 | 95 | 2016-08-03 | 2016-08-03 | 1d | 3d | 0d |
| 97 | 1.21.3 | TOMADAS E INTERRUPTORES | 30d | 2017-12-18 | 2018-01-26 | 96SS+5d | 2016-08-03 | 2016-08-03 | 1d | 3d | 0d |
| 98 | 1.21.4 | CONDULETES E CAIXAS | 133d | 2017-08-03 | 2018-02-05 | 35FS+10d | 2016-08-03 | 2016-08-03 | 1d | 17d |  |
| 99 | 1.21.5 | ELETROCALHA E CONEXÕES | 100d | 2017-07-20 | 2017-12-06 | 95SS | 2016-08-03 | 2016-08-03 | 1d | 60d |  |
| 100 | 1.21.6 | LUMINÁRIAS | 50d | 2017-12-18 | 2018-02-23 | 97SS | 2016-08-03 | 2016-08-03 | 1d | 3d |  |
| 101 | 1.21.7 | QUADROS ELÉTRICOS | 40d | 2017-12-18 | 2018-02-09 | 97SS | 2016-08-03 | 2016-08-03 | 1d | 13d |  |
| 102 | 1.22 | **INSTALAÇÕES DE REDE LÓGICA E TELEFONIA** | 160d | 2017-07-20 | 2018-02-28 |  | 2016-08-03 | 2016-08-03 | 1d | 0d |  |
| 103 | 1.22.1 | ELETROCALHAS, ELETRODUTOS E CONEXÕES | 100d | 2017-07-20 | 2017-12-06 | 95SS | 2016-08-03 | 2016-08-03 | 1d | 0d |  |
| 104 | 1.22.2 | TOMADAS E CONECTORES | 107d | 2017-08-31 | 2018-01-26 | 103SS+30d | 2016-08-03 | 2016-08-03 | 1d | 0d |  |
| 105 | 1.22.3 | FIOS E CABOS PARA REDE LÓGICA | 85d | 2017-09-21 | 2018-01-17 | 104SS+15d | 2016-08-03 | 2016-08-03 | 1d | 30d | 0d |
| 106 | 1.22.4 | CONDULETES E CAIXAS | 130d | 2017-08-31 | 2018-02-28 | 104SS | 2016-08-03 | 2016-08-03 | 1d | 0d |  |
| 107 | 1.22.5 | RACK | 30d | 2017-10-12 | 2017-11-22 | 106SS+30d | 2016-08-03 | 2016-08-03 | 1d | 70d |  |

| ID | WBS | Task | Duration | Start | Finish | Predecessors | Baseline start | Baseline finish | Baseline duration | Total slack | Free slack | Constraint |
| --- | --- | --- | --- | --- | --- | --- | --- | --- | --- | --- | --- | --- |
| 108 | 1.23 | **SISTEMAS DE CFTV** | 85d | 2017-09-21 | 2018-01-17 |  | 2016-08-03 | 2016-08-03 | 1d | 30d |  |  |
| 109 | 1.23.1 | FIOS E CABOS PARA CFTV | 85d | 2017-09-21 | 2018-01-17 | 105SS | 2016-08-03 | 2016-08-03 | 1d | 30d | 0d |  |
| 110 | 1.23.2 | MONITORAMENTO E IMAGENS | 55d | 2017-11-02 | 2018-01-17 | 111SS | 2016-08-03 | 2016-08-03 | 1d | 30d |  |  |
| 111 | 1.23.3 | FIBRA ÓPTICA | 40d | 2017-11-02 | 2017-12-27 | 109SS+30d | 2016-08-03 | 2016-08-03 | 1d | 30d | 0d |  |
| 112 | 1.24 | **INSTALAÇÕES DE SPDA** | 30d | 2017-12-01 | 2018-01-11 |  | 2016-08-03 | 2016-08-03 | 1d | 34d |  |  |
| 113 | 1.24.1 | CORDOALHAS | 30d | 2017-12-01 | 2018-01-11 | 54 | 2016-08-03 | 2016-08-03 | 1d | 34d | 0d |  |
| 114 | 1.24.2 | CAIXAS DE EQUALIZAÇÃO | 30d | 2017-12-01 | 2018-01-11 | 113SS | 2016-08-03 | 2016-08-03 | 1d | 34d |  |  |
| 115 | 1.24.3 | CONECTORES, PARAFUSOS, PRESILHAS E VEDAÇÕES | 25d | 2017-12-08 | 2018-01-11 | 113SS+5d | 2016-08-03 | 2016-08-03 | 1d | 34d |  |  |
| 116 | 1.25 | INSTALAÇÕES DE GASES | 60d | 2017-06-19 | 2017-09-08 |  | 2016-08-03 | 2016-08-03 | 1d | 123d |  | start no earlier than 2017-06-19 |
| 117 | 1.26 | **INSTALAÇÕES DE AR-CONDICIONADO** | 140.12d | 2017-07-20 | 2018-01-31 |  | 2016-08-03 | 2016-08-03 | 1d |  |  |  |
| 118 | 1.26.1 | UNIDADES CLIMATIZADORAS | 66d | 2017-10-12 | 2018-01-11 | 125SS | 2016-08-03 | 2016-08-03 | 1d | -3.12d | 0d |  |
| 119 | 1.26.2 | ACESSÓRIOS PARA CAPTAÇÃO E INSUFLAMENTO DE AR | 60d | 2017-10-12 | 2018-01-03 | 118SS | 2016-08-03 | 2016-08-03 | 1d | 40d |  |  |
| 120 | 1.26.3 | REDES DE DUTOS | 100d | 2017-07-20 | 2017-12-06 | 95SS | 2016-08-03 | 2016-08-03 | 1d | -3.12d | 0d |  |
| 121 | 1.26.4 | DUTOS FLEXÍVEIS | 100d | 2017-07-20 | 2017-12-06 | 120SS | 2016-08-03 | 2016-08-03 | 1d | 60d |  |  |
| 122 | 1.26.5 | INSTALAÇÃO ELÉTRICA | 100d | 2017-08-31 | 2018-01-17 | 120SS+30d | 2016-08-03 | 2016-08-03 | 1d | -3.12d | 0d |  |
| 123 | 1.26.6 | CABOS | 80d | 2017-10-12 | 2018-01-31 | 122SS+30d | 2016-08-03 | 2016-08-03 | 1d | -3.12d | 0d |  |
| 124 | 1.26.7 | ELETRODUTOS | 80d | 2017-07-20 | 2017-11-08 | 120SS | 2016-08-03 | 2016-08-03 | 1d | 80d |  |  |
| 125 | 1.26.8 | INTERLIGAÇÃO FRIGORÍFICA | 60d | 2017-10-12 | 2018-01-03 | 123SS | 2016-08-03 | 2016-08-03 | 1d | -3.12d | 0d |  |
| 126 | 1.26.9 | SINALIZAÇÃO VISUAL | 15d | 2018-01-16 | 2018-02-05 | 59 |  |  |  | -3.12d | 0d |  |
| 127 | 1.27 | **SERVIÇOS DE PAISAGISMO** | 45d | 2017-12-28 | 2018-02-28 |  | 2016-08-03 | 2016-08-03 | 1d | 0d |  |  |
| 128 | 1.27.1 | PAISAGISMO INTERNO | 30d | 2017-12-28 | 2018-02-07 |  |  |  |  | 0d |  | start no earlier than 2017-12-28 |
| 129 | 1.27.2 | PAISAGISMO EXTERNO | 45d | 2017-12-28 | 2018-02-28 | 128SS |  |  |  | 0d |  |  |
| 130 | 1.28 | **LIMPEZA DE OBRA TOTAL** | 382d | 2016-09-08 | 2018-02-28 |  | 2016-08-03 | 2016-08-03 | 1d | 0d |  |  |
| 131 | 1.28.1 | LIMPEZA PERMANENTE DA OBRA | 342d | 2016-09-08 | 2018-01-03 | 19SS+10d | 2016-08-03 | 2016-08-03 | 1d | 0d |  |  |
| 132 | 1.28.2 | LIMPEZA FINAL PARA ENTREGA DA OBRA | 40d | 2018-01-04 | 2018-02-28 | 131 | 2016-08-03 | 2016-08-03 | 1d | 0d |  |  |
