# Projeto 2 VH

Schedule from MS Project, 2016-08-03 to 2018-09-28.

## Calendars

- Padrão: Mon-Fri 09:00-12:00, 13:00-18:00; Sat-Sun off. Exceptions (off unless hours are given): 2016-09-07, 2016-10-12, 2016-11-02, 2016-11-15.

## Schedule

| ID | WBS | Task | Duration | Start | Finish | Predecessors | Baseline start | Baseline finish | Baseline duration | Total slack | Free slack | Constraint |
| --- | --- | --- | --- | --- | --- | --- | --- | --- | --- | --- | --- | --- |
| 1 | 1 | **TRF - 4 VARAS HORIZONTAL** | 559d | 2016-08-03 | 2018-09-28 |  | 2016-08-03 | 2018-09-13 | 548d |  |  |  |
| 2 | 1.1 | **ADMINISTRAÇÃO LOCAL** | 90d | 2016-08-03 | 2016-12-12 |  | 2016-08-03 | 2018-09-13 | 548d | 0d |  |  |
| 3 | 1.1.1 | MÃO DE OBRA INDIRETA | 30d | 2016-08-03 | 2016-09-14 |  | 2016-08-03 | 2018-09-13 | 548d | 0d |  |  |
| 4 | 1.1.2 | CONSUMOS | 30d | 2016-08-03 | 2016-09-14 | 3SS | 2016-08-03 | 2018-09-13 | 548d | 529d |  |  |
| 5 | 1.1.3 | EQUIPAMENTOS DE PROTEÇÃO COLETIVA | 30d | 2016-10-28 | 2016-12-12 | 30SS | 2016-08-03 | 2016-08-03 | 1d | 469d |  |  |
| 6 | 1.2 | **INSTALAÇÕES PROVISÓRIAS, ANDAIMES, TRANSPORTE VERTICAL** | 493d | 2016-08-25 | 2018-07-20 |  | 2016-08-25 | 2016-09-21 | 19d | 50d |  |  |
| 7 | 1.2.1 | TAPUME DE CHAPA DE MADEIRA COMPENSADA | 5d | 2016-08-25 | 2016-08-31 | 19SS+1d | 2016-08-25 | 2016-08-31 | 5d | 523d | 0d |  |
| 8 | 1.2.2 | BARRACÃO PARA ESCRITÓRIOS (CONSIDERANDO 2 DE 4,00 X 4,00 M) | 10d | 2016-08-25 | 2016-09-08 | 7SS | 2016-08-25 | 2016-09-07 | 10d | 533d |  |  |
| 9 | 1.2.3 | BARRACÃO PARA ALMOXARIFADO | 10d | 2016-08-25 | 2016-09-08 | 7SS | 2016-08-25 | 2016-09-07 | 10d | 533d |  |  |
| 10 | 1.2.4 | BARRACÃO DE SANITÁRIO, VESTIÁRIO E REFEITÓRIO | 10d | 2016-08-25 | 2016-09-08 | 7SS | 2016-08-25 | 2016-09-07 | 10d | 533d | 0d |  |
| 11 | 1.2.5 | INSTALAÇÕES PROVISÓRIAS DE ÁGUA, ESGOTO E ENERGIA | 3d | 2016-08-25 | 2016-08-29 | 7SS | 2016-08-25 | 2016-08-29 | 3d | 540d |  |  |
| 12 | 1.2.6 | PLACA DE OBRA EM CHAPA DE AÇO GALVANIZADO | 2d | 2016-08-25 | 2016-08-26 | 7SS | 2016-08-25 | 2016-08-26 | 2d | 541d |  |  |
| 13 | 1.2.7 | LOCAÇÃO DE OBRA (GABARITO) | 5d | 2016-09-16 | 2016-09-22 | 7SS+15d | 2016-09-15 | 2016-09-21 | 5d | 523d |  |  |
| 14 | 1.2.8 | LOCAÇÃO MENSAL DE ANDAIME METÁLICO TIPO FACHADEIRO, INCLUSIVE MONTAGEM | 90d | 2018-02-14 | 2018-06-19 | 54SS+1d | 2016-08-25 | 2016-08-25 | 1d | 73d | 0d |  |
| 15 | 1.2.9 | PLATAFORMA DE MADEIRA PARA ANDAIME | 90d | 2018-02-14 | 2018-06-19 | 14SS | 2016-08-25 | 2016-08-25 | 1d | 73d |  |  |
| 16 | 1.2.10 | FORNECIMENTO E LOCAÇÃO DE EQUIPAMENTOS (BETONEIRA, MAKITA, SERRA DE BANCA E VIBRADOR DE IMERSÃO) | 1d | 2016-08-29 | 2016-08-29 | 10SS+2d | 2016-08-29 | 2016-08-29 | 1d | 540d |  |  |
| 17 | 1.2.11 | DESCARGA E TRANSPORTE DE MATERIAIS ATÉ AS FRENTES DE SERVIÇO (ÁREA APROXIMADA DE 4.000 M2) | 454d | 2016-10-21 | 2018-07-20 | 29SS | 2016-08-25 | 2016-08-25 | 1d | 50d |  |  |
| 18 | 1.3 | **MOBILIZAÇÃO E DESMOBILIZAÇÃO DE OBRA** | 503d | 2016-08-24 | 2018-08-02 |  | 2016-08-24 | 2018-09-13 | 532.88d | 0d |  |  |
| 19 | 1.3.1 | MOBILIZAÇÃO E DESMOBILIZAÇÃO DE OBRA EXECUTADAS EM CENTROS URBANOS OU PRÓXIMOS DE CENTROS URBANOS | 65d | 2016-08-24 | 2018-08-02 | 3SS+15d | 2016-08-24 | 2018-09-13 | 532.88d | 0d |  |  |
| 20 | 1.4 | **SERVIÇOS TÉCNICOS E ESPECÍFICOS** | 534d | 2016-08-10 | 2018-08-31 |  | 2016-08-10 | 2016-08-10 | 1d | 20d |  |  |
| 21 | 1.4.1 | AS BUILT DE PROJETOS COM ÁREA ATÉ 10.000 M2 | 31d | 2018-07-20 | 2018-08-31 |  | 2016-08-10 | 2016-08-10 | 1d | 20d |  | start no earlier than 2018-07-20 |
| 22 | 1.4.2 | ENSAIO DE RESISTÊNCIA A COMPRESSÃO SIMPLES - CONCRETO | 60d | 2016-11-03 | 2017-01-26 | 28SS+1d | 2016-08-10 | 2016-08-10 | 1d | 436d |  |  |
| 23 | 1.4.3 | ENSAIO DE ESTANQUEIDADE DE INSTALAÇÕES HIDRÁULICAS (ÁGUA FRIA, INCÊNDIO E REDE DE DISTRIBUIÇÃO DE ÁGUA POTÁVEL) | 30d | 2018-05-17 | 2018-06-27 | 85SS | 2016-08-10 | 2016-08-10 | 1d | 67d |  |  |
| 24 | 1.4.4 | PCMAT (NR-18) E PCSMO (NR-7) | 7d | 2016-08-10 | 2016-08-18 | 3SS+5d | 2016-08-10 | 2016-08-10 | 1d | 547d |  |  |
| 25 | 1.5 | FUNDAÇÃO | 30d | 2016-09-08 | 2016-10-20 | 19SS+10d |  |  |  | 0d |  |  |

| ID | WBS | Task | Duration | Start | Finish | Predecessors | Baseline start | Baseline finish | Baseline duration | Total slack | Free slack |
| --- | --- | --- | --- | --- | --- | --- | --- | --- | --- | --- | --- |
| 26 | 1.6 | **ESTRUTURA** | 456d | 2016-10-21 | 2018-07-24 |  | 2016-08-03 | 2017-01-09 | 110d | 0d |  |
| 27 | 1.6.1 | **ESTRUTURA DE CONCRETO** | 77d | 2016-10-21 | 2017-02-08 |  | 2016-10-03 | 2017-01-09 | 68d | 0d |  |
| 28 | 1.6.1.1 | FORNECIMENTO E APLICAÇÃO DE CONCRETO USINADO BOMBEADO FCK=25MPA, INCLUSIVE LANCAMENTO E ADENSAMENTO | 70d | 2016-11-01 | 2017-02-08 | 31SS+1d | 2016-10-05 | 2017-01-09 | 66d | 0d |  |
| 29 | 1.6.1.2 | FORNECIMENTO, CORTE, DOBRA E COLOCAÇÃO DE ARMAÇÃO EM AÇO CA-50 | 70d | 2016-10-21 | 2017-01-30 | 25 | 2016-10-03 | 2017-01-05 | 66d | 0d |  |
| 30 | 1.6.1.3 | FORNECIMENTO E MONTAGEM DE FORMA PARA ESTRUTURAS DE CONCRETO (PILAR, VIGA E LAJE) FABRICAÇÃO, MONTAGEM E DESMONTAGEM - INCLUSIVE ESCORAMENTO | 70d | 2016-10-28 | 2017-02-06 | 29SS+5d | 2016-10-04 | 2017-01-06 | 66d | 0d |  |
| 31 | 1.6.1.4 | FORNECIMENTO E EXECUÇÃO DE CIMBRAMENTO/ESCORAMENTO, PARA LAJES, INCLUSIVE CARGA E DESCARGA | 70d | 2016-10-31 | 2017-02-07 | 30SS+1d | 2016-10-04 | 2017-01-06 | 66d | 0d |  |
| 32 | 1.6.2 | **ESTRUTURA METÁLICA** | 45d | 2018-05-23 | 2018-07-24 |  | 2016-08-03 | 2016-08-03 | 1d | 48d |  |
| 33 | 1.6.2.1 | FORNECIMENTO E MONTAGEM DE PERFIS METÁLICOS EM AÇO LAMINADO TIPO "I", PINTADO NA COR CINZA | 45d | 2018-05-23 | 2018-07-24 | 54FS+1d | 2016-08-03 | 2016-08-03 | 1d | 48d |  |
| 34 | 1.7 | **ALVENARIA, DIVISÓRIAS, VERGAS E CONTRA-VERGAS** | 211d | 2017-02-10 | 2017-12-01 |  | 2016-08-03 | 2016-08-03 | 1d | 4d |  |
| 35 | 1.7.1 | ALVENARIAS DE BLOCO DE CONCRETO, VERGAS E CONTRAVERGAS | 180d | 2017-02-10 | 2017-10-19 | 28FS+1d | 2016-08-03 | 2016-08-03 | 1d | 4d | 0d |
| 36 | 1.7.2 | PAREDES DE GESSO ACARTONADO | 30d | 2017-10-23 | 2017-12-01 | 35FS+1d | 2016-08-03 | 2016-08-03 | 1d | 215d |  |
| 37 | 1.8 | **ESQUADRIAS E FERRAGENS** | 226d | 2017-10-20 | 2018-08-31 |  | 2016-08-03 | 2016-08-03 | 1d | 9d |  |
| 38 | 1.8.1 | ESQUADRIAS DE MADEIRA - PORTAS | 60d | 2017-10-20 | 2018-01-11 | 35 | 2016-08-03 | 2016-08-03 | 1d | 181d | 0d |
| 39 | 1.8.2 | ESQUADRIAS DE ALUMÍNIO - PORTAS | 15d | 2017-10-27 | 2017-11-16 | 35FS+5d | 2016-08-03 | 2016-08-03 | 1d | 4d | 0d |
| 40 | 1.8.3 | ESQUADRIAS DE ALUMÍNIO - JANELAS | 60d | 2017-11-20 | 2018-02-09 | 39FS+1d | 2016-08-03 | 2016-08-03 | 1d | 4d | 0d |
| 41 | 1.8.4 | ESQUADRIAS DE PELE DE VIDRO E ALUMÍNIO - JANELAS | 73d | 2018-05-23 | 2018-08-31 | 54FS+1d | 2016-08-03 | 2016-08-03 | 1d | 20d |  |
| 42 | 1.8.5 | ESQUADRIAS METÁLICAS - PORTAS | 30d | 2018-02-13 | 2018-03-26 | 40FS+1d | 2016-08-03 | 2016-08-03 | 1d | 134d |  |
| 43 | 1.8.6 | FERRAGENS | 60d | 2017-10-27 | 2018-01-18 | 38SS+5d | 2016-08-03 | 2016-08-03 | 1d | 181d |  |
| 44 | 1.9 | **VIDROS E ESPELHOS** | 60d | 2018-05-23 | 2018-08-14 |  | 2016-08-03 | 2016-08-03 | 1d | 33d |  |
| 45 | 1.9.1 | VIDROS LISOS E TEMPERADOS | 60d | 2018-05-23 | 2018-08-14 | 54FS+1d | 2016-08-03 | 2016-08-03 | 1d | 33d | 0d |
| 46 | 1.9.2 | ESPELHOS | 30d | 2018-05-23 | 2018-07-03 | 45SS | 2016-08-03 | 2016-08-03 | 1d | 63d |  |
| 47 | 1.10 | **COBERTURA** | 90d | 2017-11-10 | 2018-03-15 |  | 2016-08-03 | 2016-08-03 | 1d | 141d |  |
| 48 | 1.10.1 | COBERTURA COM TELHAS SANDUÍCHE | 80d | 2017-11-10 | 2018-03-01 | 35FS+15d | 2016-08-03 | 2016-08-03 | 1d | 141d | 0d |
| 49 | 1.10.2 | RUFOS, CALHAS E CHAPINS | 10d | 2018-03-02 | 2018-03-15 | 48 | 2016-08-03 | 2016-08-03 | 1d | 141d |  |
| 50 | 1.11 | IMPERMEABILIZAÇÃO E ISOLAMENTO TÉRMICO | 90d | 2018-04-17 | 2018-08-20 | 61SS+5d | 2016-08-03 | 2016-08-03 | 1d | 29d |  |

| ID | WBS | Task | Duration | Start | Finish | Predecessors | Baseline start | Baseline finish | Baseline duration | Total slack | Free slack | Constraint |
| --- | --- | --- | --- | --- | --- | --- | --- | --- | --- | --- | --- | --- |
| 51 | 1.12 | **REVESTIMENTOS** | 130d | 2018-02-13 | 2018-08-13 |  | 2016-08-03 | 2016-08-03 | 1d | 4d |  |  |
| 52 | 1.12.1 | REVESTIMENTOS INTERNOS DE ARGAMASSA | 45d | 2018-02-13 | 2018-04-16 | 40FS+1d | 2016-08-03 | 2016-08-03 | 1d | 4d | 0d |  |
| 53 | 1.12.2 | REVESTIMENTOS DE PAREDES | 100d | 2018-03-27 | 2018-08-13 | 52SS+30d | 2016-08-03 | 2016-08-03 | 1d | 4d | 0d |  |
| 54 | 1.12.3 | REVESTIMENTOS EXTERNOS DE ARGAMASSA | 70d | 2018-02-13 | 2018-05-21 | 40FS+1d | 2016-08-03 | 2016-08-03 | 1d | 20d | 0d |  |
| 55 | 1.13 | FORROS | 52d | 2018-04-06 | 2018-06-18 | 117FS+1d | 2016-08-03 | 2016-08-03 | 1d | 0d |  |  |
| 56 | 1.14 | **MARCENARIA E SERRALHERIA** | 90d | 2018-05-22 | 2018-09-24 |  |  |  |  | 4d |  |  |
| 57 | 1.14.1 | ARMÁRIO E PAINEL | 30d | 2018-08-14 | 2018-09-24 | 53 |  |  |  | 4d |  |  |
| 58 | 1.14.2 | SERRALHERIA | 30d | 2018-05-22 | 2018-07-02 | 54 |  |  |  | 64d |  |  |
| 59 | 1.15 | PINTURA | 74d | 2018-06-19 | 2018-09-28 | 55 | 2016-08-03 | 2016-08-03 | 1d | 0d |  |  |
| 60 | 1.16 | **PISOS** | 104d | 2018-04-10 | 2018-08-31 |  | 2016-08-03 | 2016-08-03 | 1d | 20d |  |  |
| 61 | 1.16.1 | CONTRAPISO | 55d | 2018-04-10 | 2018-06-25 | 53SS+10d | 2016-08-03 | 2016-08-03 | 1d | 20d | 0d | start no earlier than 2018-03-02 |
| 62 | 1.16.2 | PISOS EM PORCELANATOS | 60d | 2018-04-17 | 2018-07-09 | 61SS+5d | 2016-08-03 | 2016-08-03 | 1d | 59d | 0d |  |
| 63 | 1.16.3 | PISOS DE GRANILITE | 98d | 2018-04-11 | 2018-08-24 | 61SS+1d | 2016-08-03 | 2016-08-03 | 1d | 20d | 0d |  |
| 64 | 1.16.4 | PISO ELEVADO | 30d | 2018-04-11 | 2018-05-22 | 63SS | 2016-08-03 | 2016-08-03 | 1d | 93d |  |  |
| 65 | 1.16.5 | PISO TÁTIL | 5d | 2018-08-27 | 2018-08-31 | 63 | 2016-08-03 | 2016-08-03 | 1d | 20d |  |  |
| 66 | 1.16.6 | **RODAPÉS, SOLEIRAS E PEITORIS** | 51d | 2018-04-24 | 2018-07-03 |  | 2016-08-03 | 2016-08-03 | 1d | 63d |  |  |
| 67 | 1.16.6.1 | RODAPÉS | 30d | 2018-05-23 | 2018-07-03 | 63SS+30d | 2016-08-03 | 2016-08-03 | 1d | 63d |  |  |
| 68 | 1.16.6.2 | SOLEIRAS E PEITORIS | 30d | 2018-04-24 | 2018-06-04 | 62SS+5d | 2016-08-03 | 2016-08-03 | 1d | 84d |  |  |
| 69 | 1.17 | **APARELHOS E METAIS** | 76d | 2018-05-18 | 2018-08-31 |  | 2016-08-03 | 2016-08-03 | 1d | 20d |  |  |
| 70 | 1.17.1 | VÁLVULAS | 16d | 2018-08-10 | 2018-08-31 | 73 | 2016-08-03 | 2016-08-03 | 1d | 20d |  |  |
| 71 | 1.17.2 | TORNEIRAS | 16d | 2018-08-10 | 2018-08-31 | 73 | 2016-08-03 | 2016-08-03 | 1d | 20d |  |  |
| 72 | 1.17.3 | BACIAS SANITÁRIAS E ASSENTOS | 60d | 2018-05-18 | 2018-08-09 | 81FS+1d | 2016-08-03 | 2016-08-03 | 1d | 36d |  |  |
| 73 | 1.17.4 | LAVATÓRIOS | 60d | 2018-05-18 | 2018-08-09 | 81FS+1d | 2016-08-03 | 2016-08-03 | 1d | 20d | 0d |  |
| 74 | 1.17.5 | DISPENSER | 15d | 2018-08-13 | 2018-08-31 | 73FS+1d | 2016-08-03 | 2016-08-03 | 1d | 20d |  |  |
| 75 | 1.17.6 | ALARME | 10d | 2018-08-13 | 2018-08-24 | 73FS+1d | 2016-08-03 | 2016-08-03 | 1d | 25d |  |  |
| 76 | 1.17.7 | BARRA DE APOIO | 10d | 2018-08-13 | 2018-08-24 | 73FS+1d | 2016-08-03 | 2016-08-03 | 1d | 25d |  |  |
| 77 | 1.17.8 | DIVERSOS | 15d | 2018-08-13 | 2018-08-31 | 73FS+1d | 2016-08-03 | 2016-08-03 | 1d | 20d |  |  |
| 78 | 1.18 | BANCADAS | 60d | 2018-05-18 | 2018-08-09 | 73SS | 2016-08-03 | 2016-08-03 | 1d | 36d |  |  |

| ID | WBS | Task | Duration | Start | Finish | Predecessors | Baseline start | Baseline finish | Baseline duration | Total slack | Free slack |
| --- | --- | --- | --- | --- | --- | --- | --- | --- | --- | --- | --- |
| 79 | 1.19 | **INSTALAÇÕES HIDRÁULICAS E SANITÁRIAS** | 315d | 2017-03-23 | 2018-06-06 |  | 2016-08-03 | 2016-08-03 | 1d | 20d |  |
| 80 | 1.19.1 | REGISTROS | 30d | 2017-06-15 | 2017-07-26 | 81SS+60d | 2016-08-03 | 2016-08-03 | 1d | 307d |  |
| 81 | 1.19.2 | TUBOS E CONEXÕES DE ÁGUA FRIA | 300d | 2017-03-23 | 2018-05-16 | 82SS | 2016-08-03 | 2016-08-03 | 1d | 20d | 0d |
| 82 | 1.19.3 | TUBOS E CONEXÕES DE ESGOTO SANITÁRIO | 300d | 2017-03-23 | 2018-05-16 | 28FS+30d | 2016-08-03 | 2016-08-03 | 1d | 20d | 0d |
| 83 | 1.19.4 | TUBOS E CONEXÕES DE ÁGUAS PLUVIAIS | 100d | 2017-05-04 | 2017-09-20 | 82SS+30d | 2016-08-03 | 2016-08-03 | 1d | 236d | 0d |
| 84 | 1.19.5 | CAIXAS SIFONADAS E RALOS | 30d | 2017-09-22 | 2017-11-02 | 83FS+1d | 2016-08-03 | 2016-08-03 | 1d | 236d |  |
| 85 | 1.19.6 | RESERVATÓRIOS | 15d | 2018-05-17 | 2018-06-06 | 81 | 2016-08-03 | 2016-08-03 | 1d | 67d | 0d |
| 86 | 1.20 | **INSTALAÇÕES DE PROTEÇÃO E COMBATE A INCÊNDIO** | 147d | 2017-05-04 | 2017-11-24 |  | 2016-08-03 | 2016-08-03 | 1d | 220d |  |
| 87 | 1.20.1 | TUBO DE AÇO GALVANIZADO | 100d | 2017-05-04 | 2017-09-20 | 81SS+30d | 2016-08-03 | 2016-08-03 | 1d | 220d | 0d |
| 88 | 1.20.2 | HIDRANTE | 30d | 2017-09-22 | 2017-11-02 | 87FS+1d | 2016-08-03 | 2016-08-03 | 1d | 236d |  |
| 89 | 1.20.3 | EXTINTORES | 30d | 2017-09-22 | 2017-11-02 | 87FS+1d | 2016-08-03 | 2016-08-03 | 1d | 220d | 0d |
| 90 | 1.20.4 | PLACAS | 15d | 2017-11-06 | 2017-11-24 | 89FS+1d | 2016-08-03 | 2016-08-03 | 1d | 220d |  |
| 91 | 1.20.5 | ALARME DE INCÊNDIO | 30d | 2017-09-22 | 2017-11-02 | 87FS+1d | 2016-08-03 | 2016-08-03 | 1d | 236d |  |
| 92 | 1.20.6 | ILUMINAÇÃO DE EMERGÊNCIA | 30d | 2017-09-22 | 2017-11-02 | 87FS+1d | 2016-08-03 | 2016-08-03 | 1d | 236d |  |
| 93 | 1.20.7 | BOMBA | 15d | 2017-09-22 | 2017-10-12 | 87FS+1d | 2016-08-03 | 2016-08-03 | 1d | 251d |  |
| 94 | 1.21 | **INSTALAÇÕES ELÉTRICAS** | 395d | 2017-03-23 | 2018-09-26 |  | 2016-08-03 | 2016-08-03 | 1d | 0d |  |
| 95 | 1.21.1 | ELETRODUTOS E CONEXÕES | 250d | 2017-03-23 | 2018-03-07 | 28FS+30d | 2016-08-03 | 2016-08-03 | 1d | 0d |  |
| 96 | 1.21.2 | FIOS E CABOS | 60d | 2018-03-08 | 2018-05-30 | 95 | 2016-08-03 | 2016-08-03 | 1d | 2d | 0d |
| 97 | 1.21.3 | TOMADAS E INTERRUPTORES | 30d | 2018-05-31 | 2018-07-11 | 96 | 2016-08-03 | 2016-08-03 | 1d | 2d | 0d |
| 98 | 1.21.4 | CONDULETES E CAIXAS | 200d | 2017-03-23 | 2017-12-27 | 28FS+30d | 2016-08-03 | 2016-08-03 | 1d | 197d |  |
| 99 | 1.21.5 | ELETROCALHA E CONEXÕES | 200d | 2017-03-23 | 2017-12-27 | 95SS | 2016-08-03 | 2016-08-03 | 1d | 197d |  |
| 100 | 1.21.6 | LUMINÁRIAS | 85d | 2018-05-31 | 2018-09-26 | 97SS | 2016-08-03 | 2016-08-03 | 1d | 2d |  |
| 101 | 1.21.7 | QUADROS ELÉTRICOS | 60d | 2018-05-31 | 2018-08-22 | 97SS | 2016-08-03 | 2016-08-03 | 1d | 27d |  |
| 102 | 1.22 | **INSTALAÇÕES DE REDE LÓGICA E TELEFONIA** | 350d | 2017-03-23 | 2018-07-25 |  | 2016-08-03 | 2016-08-03 | 1d | 17d |  |
| 103 | 1.22.1 | ELETROCALHAS, ELETRODUTOS E CONEXÕES | 250d | 2017-03-23 | 2018-03-07 | 95SS | 2016-08-03 | 2016-08-03 | 1d | 17d | 0d |
| 104 | 1.22.2 | TOMADAS E CONECTORES | 200d | 2017-05-04 | 2018-02-07 | 103SS+30d | 2016-08-03 | 2016-08-03 | 1d | 17d | 0d |
| 105 | 1.22.3 | FIOS E CABOS PARA REDE LÓGICA | 120d | 2018-02-08 | 2018-07-25 | 104 | 2016-08-03 | 2016-08-03 | 1d | 17d | 0d |
| 106 | 1.22.4 | CONDULETES E CAIXAS | 200d | 2017-05-04 | 2018-02-07 | 104SS | 2016-08-03 | 2016-08-03 | 1d | 167d | 0d |
| 107 | 1.22.5 | RACK | 30d | 2017-06-15 | 2017-07-26 | 106SS+30d | 2016-08-03 | 2016-08-03 | 1d | 307d |  |

| ID | WBS | Task | Duration | Start | Finish | Predecessors | Baseline start | Baseline finish | Baseline duration | Total slack | Free slack | Constraint |
| --- | --- | --- | --- | --- | --- | --- | --- | --- | --- | --- | --- | --- |
| 108 | 1.23 | **SISTEMAS DE CFTV** | 150d | 2018-02-08 | 2018-09-05 |  | 2016-08-03 | 2016-08-03 | 1d | 17d |  |  |
| 109 | 1.23.1 | FIOS E CABOS PARA CFTV | 120d | 2018-02-08 | 2018-07-25 | 105SS | 2016-08-03 | 2016-08-03 | 1d | 17d | 0d |  |
| 110 | 1.23.2 | MONITORAMENTO E IMAGENS | 90d | 2018-05-03 | 2018-09-05 | 111SS+30d | 2016-08-03 | 2016-08-03 | 1d | 17d |  |  |
| 111 | 1.23.3 | FIBRA ÓPTICA | 60d | 2018-03-22 | 2018-06-13 | 109SS+30d | 2016-08-03 | 2016-08-03 | 1d | 17d | 0d |  |
| 112 | 1.24 | **INSTALAÇÕES DE SPDA** | 65d | 2018-05-22 | 2018-08-20 |  | 2016-08-03 | 2016-08-03 | 1d | 29d |  |  |
| 113 | 1.24.1 | CORDOALHAS | 60d | 2018-05-22 | 2018-08-13 | 54 | 2016-08-03 | 2016-08-03 | 1d | 29d | 0d |  |
| 114 | 1.24.2 | CAIXAS DE EQUALIZAÇÃO | 30d | 2018-05-22 | 2018-07-02 | 113SS | 2016-08-03 | 2016-08-03 | 1d | 64d |  |  |
| 115 | 1.24.3 | CONECTORES, PARAFUSOS, PRESILHAS E VEDAÇÕES | 60d | 2018-05-29 | 2018-08-20 | 113SS+5d | 2016-08-03 | 2016-08-03 | 1d | 29d |  |  |
| 116 | 1.25 | INSTALAÇÕES DE GASES | 60d | 2017-07-24 | 2017-10-13 |  | 2016-08-03 | 2016-08-03 | 1d | 250d |  | start no earlier than 2017-07-24 |
| 117 | 1.26 | **INSTALAÇÕES DE AR-CONDICIONADO** | 270d | 2017-03-23 | 2018-04-04 |  | 2016-08-03 | 2016-08-03 | 1d | 0d |  |  |
| 118 | 1.26.1 | UNIDADES CLIMATIZADORAS | 90d | 2017-11-30 | 2018-04-04 | 125SS | 2016-08-03 | 2016-08-03 | 1d | 0d |  |  |
| 119 | 1.26.2 | ACESSÓRIOS PARA CAPTAÇÃO E INSUFLAMENTO DE AR | 90d | 2017-11-30 | 2018-04-04 | 118SS | 2016-08-03 | 2016-08-03 | 1d | 0d |  |  |
| 120 | 1.26.3 | REDES DE DUTOS | 120d | 2017-03-23 | 2017-09-06 | 95SS | 2016-08-03 | 2016-08-03 | 1d | 0d |  |  |
| 121 | 1.26.4 | DUTOS FLEXÍVEIS | 120d | 2017-03-23 | 2017-09-06 | 120SS | 2016-08-03 | 2016-08-03 | 1d | 150d |  |  |
| 122 | 1.26.5 | INSTALAÇÃO ELÉTRICA | 120d | 2017-05-04 | 2017-10-18 | 120SS+30d | 2016-08-03 | 2016-08-03 | 1d | 0d |  |  |
| 123 | 1.26.6 | CABOS | 90d | 2017-10-19 | 2018-02-21 | 122 | 2016-08-03 | 2016-08-03 | 1d | 0d |  |  |
| 124 | 1.26.7 | ELETRODUTOS | 90d | 2017-03-23 | 2017-07-26 | 120SS | 2016-08-03 | 2016-08-03 | 1d | 180d |  |  |
| 125 | 1.26.8 | INTERLIGAÇÃO FRIGORÍFICA | 90d | 2017-11-30 | 2018-04-04 | 123SS+30d | 2016-08-03 | 2016-08-03 | 1d | 0d |  |  |
| 126 | 1.27 | SINALIZAÇÃO VISUAL | 15d | 2018-09-10 | 2018-09-28 | 59SS+10d |  |  |  | 0d |  | start no earlier than 2018-09-10 |
| 127 | 1.28 | **SERVIÇOS DE PAISAGISMO** | 45d | 2018-07-02 | 2018-08-31 |  | 2016-08-03 | 2016-08-03 | 1d | 20d |  |  |
| 128 | 1.28.1 | PAISAGISMO INTERNO | 30d | 2018-07-02 | 2018-08-10 |  |  |  |  | 20d | 0d | start no earlier than 2018-07-02 |
| 129 | 1.28.2 | PAISAGISMO EXTERNO | 45d | 2018-07-02 | 2018-08-31 | 128SS |  |  |  | 20d |  |  |
| 130 | 1.29 | **LIMPEZA DE OBRA TOTAL** | 514d | 2016-09-08 | 2018-08-31 |  | 2016-08-03 | 2016-08-03 | 1d | 20d |  |  |
| 131 | 1.29.1 | LIMPEZA PERMANENTE DA OBRA | 474d | 2016-09-08 | 2018-07-06 | 19SS+10d | 2016-08-03 | 2016-08-03 | 1d | 20d | 0d |  |
| 132 | 1.29.2 | LIMPEZA FINAL PARA ENTREGA DA OBRA | 40d | 2018-07-09 | 2018-08-31 | 131 | 2016-08-03 | 2016-08-03 | 1d | 20d |  | start no earlier than 2018-06-17 |
