# Projeto 2 VH

Schedule from MS Project, 2016-08-03 to 2018-08-31.

## Calendars

- Padrão: Mon-Fri 09:00-12:00, 13:00-18:00; Sat-Sun off. Exceptions (off unless hours are given): 2016-09-07, 2016-10-12, 2016-11-02, 2016-11-15.

## Schedule

| ID | WBS | Task | Duration | Start | Finish | Predecessors | Baseline start | Baseline finish | Baseline duration | Total slack | Free slack | Constraint |
| --- | --- | --- | --- | --- | --- | --- | --- | --- | --- | --- | --- | --- |
| 1 | 1 | **TRF - 4 VARAS VERTICAL** | 539d? | 2016-08-03 | 2018-08-31 |  | 2016-08-03 | 2018-09-13 | 548d | 0d |  |  |
| 2 | 1.1 | **ADMINISTRAÇÃO LOCAL** | 511d | 2016-08-03 | 2018-07-24 |  | 2016-08-03 | 2018-09-13 | 548d | 0d |  |  |
| 3 | 1.1.1 | MÃO DE OBRA INDIRETA | 30d | 2016-08-03 | 2016-09-14 |  | 2016-08-03 | 2018-09-13 | 548d | 0d |  |  |
| 4 | 1.1.2 | CONSUMOS | 509d | 2016-08-03 | 2018-07-20 | 3SS | 2016-08-03 | 2018-09-13 | 548d | 30d |  |  |
| 5 | 1.1.3 | EQUIPAMENTOS DE PROTEÇÃO COLETIVA | 451d | 2016-10-28 | 2018-07-24 | 31SS | 2016-08-03 | 2016-08-03 | 1d | 28d |  |  |
| 6 | 1.2 | **INSTALAÇÕES PROVISÓRIAS, ANDAIMES, TRANSPORTE VERTICAL** | 493d | 2016-08-25 | 2018-07-20 |  | 2016-08-25 | 2016-09-21 | 19d | 30d |  |  |
| 7 | 1.2.1 | TAPUME DE CHAPA DE MADEIRA COMPENSADA | 5d | 2016-08-25 | 2016-08-31 | 20SS+1d | 2016-08-25 | 2016-08-31 | 5d | 503d | 0d |  |
| 8 | 1.2.2 | BARRACÃO PARA ESCRITÓRIOS (CONSIDERANDO 2 DE 4,00 X 4,00 M) | 10d | 2016-08-25 | 2016-09-08 | 7SS | 2016-08-25 | 2016-09-07 | 10d | 513d |  |  |
| 9 | 1.2.3 | BARRACÃO PARA ALMOXARIFADO | 10d | 2016-08-25 | 2016-09-08 | 7SS | 2016-08-25 | 2016-09-07 | 10d | 513d |  |  |
| 10 | 1.2.4 | BARRACÃO DE SANITÁRIO, VESTIÁRIO E REFEITÓRIO | 10d | 2016-08-25 | 2016-09-08 | 7SS | 2016-08-25 | 2016-09-07 | 10d | 513d | 0d |  |
| 11 | 1.2.5 | INSTALAÇÕES PROVISÓRIAS DE ÁGUA, ESGOTO E ENERGIA | 3d | 2016-08-25 | 2016-08-29 | 7SS | 2016-08-25 | 2016-08-29 | 3d | 520d |  |  |
| 12 | 1.2.6 | PLACA DE OBRA EM CHAPA DE AÇO GALVANIZADO | 2d | 2016-08-25 | 2016-08-26 | 7SS | 2016-08-25 | 2016-08-26 | 2d | 521d |  |  |
| 13 | 1.2.7 | LOCAÇÃO DE OBRA (GABARITO) | 5d | 2016-09-16 | 2016-09-22 | 7SS+15d | 2016-09-15 | 2016-09-21 | 5d | 503d |  |  |
| 14 | 1.2.8 | LOCAÇÃO MENSAL DE ANDAIME METÁLICO TIPO FACHADEIRO, INCLUSIVE MONTAGEM | 90d | 2018-02-14 | 2018-06-19 | 54SS+1d | 2016-08-25 | 2016-08-25 | 1d | 53d | 0d |  |
| 15 | 1.2.9 | PLATAFORMA DE MADEIRA PARA ANDAIME | 90d | 2018-02-14 | 2018-06-19 | 14SS | 2016-08-25 | 2016-08-25 | 1d | 53d |  |  |
| 16 | 1.2.10 | GUINCHO MANUAL | 100d | 2018-02-13 | 2018-07-02 | 54SS | 2016-08-25 | 2016-08-25 | 1d | 44d |  |  |
| 17 | 1.2.11 | FORNECIMENTO E LOCAÇÃO DE EQUIPAMENTOS (BETONEIRA, MAKITA, SERRA DE BANCA E VIBRADOR DE IMERSÃO) | 1d | 2016-08-29 | 2016-08-29 | 10SS+2d | 2016-08-29 | 2016-08-29 | 1d | 520d |  |  |
| 18 | 1.2.12 | DESCARGA E TRANSPORTE DE MATERIAIS ATÉ AS FRENTES DE SERVIÇO (ÁREA APROXIMADA DE 4.000 M2) | 454d | 2016-10-21 | 2018-07-20 | 30SS | 2016-08-25 | 2016-08-25 | 1d | 30d |  |  |
| 19 | 1.3 | **MOBILIZAÇÃO E DESMOBILIZAÇÃO DE OBRA** | 503d | 2016-08-24 | 2018-08-02 |  | 2016-08-24 | 2018-09-13 | 532.88d | 0d |  |  |
| 20 | 1.3.1 | MOBILIZAÇÃO E DESMOBILIZAÇÃO DE OBRA EXECUTADAS EM CENTROS URBANOS OU PRÓXIMOS DE CENTROS URBANOS | 65d | 2016-08-24 | 2018-08-02 | 3SS+15d | 2016-08-24 | 2018-09-13 | 532.88d | 0d |  |  |
| 21 | 1.4 | **SERVIÇOS TÉCNICOS E ESPECÍFICOS** | 534d | 2016-08-10 | 2018-08-31 |  | 2016-08-10 | 2016-08-10 | 1d | 0d |  |  |
| 22 | 1.4.1 | AS BUILT DE PROJETOS COM ÁREA ATÉ 10.000 M2 | 31d | 2018-07-20 | 2018-08-31 |  | 2016-08-10 | 2016-08-10 | 1d | 0d |  | start no earlier than 2018-07-20 |
| 23 | 1.4.2 | ENSAIO DE RESISTÊNCIA A COMPRESSÃO SIMPLES - CONCRETO | 60d | 2016-11-03 | 2017-01-26 | 29SS+1d | 2016-08-10 | 2016-08-10 | 1d | 416d |  |  |
| 24 | 1.4.3 | ENSAIO DE ESTANQUEIDADE DE INSTALAÇÕES HIDRÁULICAS (ÁGUA FRIA, INCÊNDIO E REDE DE DISTRIBUIÇÃO DE ÁGUA POTÁVEL) | 30d | 2018-05-17 | 2018-06-27 | 86SS | 2016-08-10 | 2016-08-10 | 1d | 47d |  |  |
| 25 | 1.4.4 | PCMAT (NR-18) E PCSMO (NR-7) | 7d | 2016-08-10 | 2016-08-18 | 3SS+5d | 2016-08-10 | 2016-08-10 | 1d | 527d |  |  |
| 26 | 1.5 | FUNDAÇÃO | 30d | 2016-09-08 | 2016-10-20 | 20SS+10d |  |  |  | 0d |  |  |

| ID | WBS | Task | Duration | Start | Finish | Predecessors | Baseline start | Baseline finish | Baseline duration | Total slack | Free slack |
| --- | --- | --- | --- | --- | --- | --- | --- | --- | --- | --- | --- |
| 27 | 1.6 | **ESTRUTURA** | 476d | 2016-10-21 | 2018-08-21 |  | 2016-08-03 | 2017-01-09 | 110d | 0d |  |
| 28 | 1.6.1 | **ESTRUTURA DE CONCRETO** | 77d | 2016-10-21 | 2017-02-08 |  | 2016-10-03 | 2017-01-09 | 68d | 0d |  |
| 29 | 1.6.1.1 | FORNECIMENTO E APLICAÇÃO DE CONCRETO USINADO BOMBEADO FCK=25MPA, INCLUSIVE LANCAMENTO E ADENSAMENTO | 70d | 2016-11-01 | 2017-02-08 | 32SS+1d | 2016-10-05 | 2017-01-09 | 66d | 0d |  |
| 30 | 1.6.1.2 | FORNECIMENTO, CORTE, DOBRA E COLOCAÇÃO DE ARMAÇÃO EM AÇO CA-50 | 70d | 2016-10-21 | 2017-01-30 | 26 | 2016-10-03 | 2017-01-05 | 66d | 0d |  |
| 31 | 1.6.1.3 | FORNECIMENTO E MONTAGEM DE FORMA PARA ESTRUTURAS DE CONCRETO (PILAR, VIGA E LAJE) FABRICAÇÃO, MONTAGEM E DESMONTAGEM - INCLUSIVE ESCORAMENTO | 70d | 2016-10-28 | 2017-02-06 | 30SS+5d | 2016-10-04 | 2017-01-06 | 66d | 0d |  |
| 32 | 1.6.1.4 | FORNECIMENTO E EXECUÇÃO DE CIMBRAMENTO/ESCORAMENTO, PARA LAJES, INCLUSIVE CARGA E DESCARGA | 70d | 2016-10-31 | 2017-02-07 | 31SS+1d | 2016-10-04 | 2017-01-06 | 66d | 0d |  |
| 33 | 1.6.2 | **ESTRUTURA METÁLICA** | 45d | 2018-06-20 | 2018-08-21 |  | 2016-08-03 | 2016-08-03 | 1d | 8d |  |
| 34 | 1.6.2.1 | FORNECIMENTO E MONTAGEM DE PERFIS METÁLICOS EM AÇO LAMINADO TIPO "I", PINTADO NA COR CINZA | 45d | 2018-06-20 | 2018-08-21 | 54FS+1d | 2016-08-03 | 2016-08-03 | 1d | 8d |  |
| 35 | 1.7 | **ALVENARIAS DE TIJOLOS FURADOS** | 211d | 2017-02-10 | 2017-12-01 |  | 2016-08-03 | 2016-08-03 | 1d | 0d |  |
| 36 | 1.7.1 | ALVENARIAS DE BLOCO DE CONCRETO, VERGAS E CONTRAVERGAS | 180d | 2017-02-10 | 2017-10-19 | 29FS+1d | 2016-08-03 | 2016-08-03 | 1d | 0d |  |
| 37 | 1.7.2 | PAREDES DE GESSO ACARTONADO | 30d | 2017-10-23 | 2017-12-01 | 36FS+1d | 2016-08-03 | 2016-08-03 | 1d | 195d |  |
| 38 | 1.8 | **ESQUADRIAS E FERRAGENS** | 112d | 2017-10-20 | 2018-03-26 |  | 2016-08-03 | 2016-08-03 | 1d | 5d |  |
| 39 | 1.8.1 | ESQUADRIAS DE MADEIRA - PORTAS | 60d | 2017-10-20 | 2018-01-11 | 36 | 2016-08-03 | 2016-08-03 | 1d | 161d | 0d |
| 40 | 1.8.2 | ESQUADRIAS DE ALUMÍNIO - PORTAS | 15d | 2017-10-27 | 2017-11-16 | 36FS+5d | 2016-08-03 | 2016-08-03 | 1d | 0d |  |
| 41 | 1.8.3 | ESQUADRIAS DE ALUMÍNIO - JANELAS | 60d | 2017-11-20 | 2018-02-09 | 40FS+1d | 2016-08-03 | 2016-08-03 | 1d | 0d |  |
| 42 | 1.8.4 | ESQUADRIAS METÁLICAS - PORTAS | 30d | 2018-02-13 | 2018-03-26 | 41FS+1d | 2016-08-03 | 2016-08-03 | 1d | 114d |  |
| 43 | 1.8.5 | FERRAGENS | 60d | 2017-10-27 | 2018-01-18 | 39SS+5d | 2016-08-03 | 2016-08-03 | 1d | 161d |  |
| 44 | 1.9 | **VIDROS E ESPELHOS** | 53d | 2018-06-20 | 2018-08-31 |  | 2016-08-03 | 2016-08-03 | 1d | 0d |  |
| 45 | 1.9.1 | VIDROS LISOS E TEMPERADOS | 53d | 2018-06-20 | 2018-08-31 | 54FS+1d | 2016-08-03 | 2016-08-03 | 1d | 0d |  |
| 46 | 1.9.2 | ESPELHOS | 30d | 2018-06-20 | 2018-07-31 | 45SS | 2016-08-03 | 2016-08-03 | 1d | 23d |  |
| 47 | 1.10 | **COBERTURA** | 90d | 2017-11-10 | 2018-03-15 |  | 2016-08-03 | 2016-08-03 | 1d | 121d |  |
| 48 | 1.10.1 | COBERTURA COM TELHAS SANDUÍCHE | 80d | 2017-11-10 | 2018-03-01 | 36FS+15d | 2016-08-03 | 2016-08-03 | 1d | 121d | 0d |
| 49 | 1.10.2 | RUFOS, CALHAS E CHAPINS | 10d | 2018-03-02 | 2018-03-15 | 48 | 2016-08-03 | 2016-08-03 | 1d | 121d |  |
| 50 | 1.11 | IMPERMEABILIZAÇÃO E ISOLAMENTO TÉRMICO | 90d | 2018-04-24 | 2018-08-27 | 62SS+5d | 2016-08-03 | 2016-08-03 | 1d | 4d |  |

| ID | WBS | Task | Duration | Start | Finish | Predecessors | Baseline start | Baseline finish | Baseline duration | Total slack | Free slack | Constraint |
| --- | --- | --- | --- | --- | --- | --- | --- | --- | --- | --- | --- | --- |
| 51 | 1.12 | **REVESTIMENTOS** | 130d | 2018-02-13 | 2018-08-13 |  | 2016-08-03 | 2016-08-03 | 1d | 0d |  |  |
| 52 | 1.12.1 | REVESTIMENTOS INTERNOS DE ARGAMASSA | 45d | 2018-02-13 | 2018-04-16 | 41FS+1d | 2016-08-03 | 2016-08-03 | 1d | 0d |  |  |
| 53 | 1.12.2 | REVESTIMENTOS DE PAREDES | 100d | 2018-03-27 | 2018-08-13 | 52SS+30d | 2016-08-03 | 2016-08-03 | 1d | 0d |  |  |
| 54 | 1.12.3 | REVESTIMENTOS EXTERNOS DE ARGAMASSA | 90d | 2018-02-13 | 2018-06-18 | 41FS+1d | 2016-08-03 | 2016-08-03 | 1d | 0d |  |  |
| 55 | 1.13 | FORROS | 31d | 2018-04-06 | 2018-05-18 | 118FS+1d | 2016-08-03 | 2016-08-03 | 1d | 0d |  |  |
| 56 | 1.14 | MARCENARIA E SERRALHERIA | 1d? | 2016-08-03 | 2016-08-03 |  |  |  |  | 538d |  |  |
| 57 | 1.15 | ARMÁRIO E PAINEL | 24d | 2018-07-31 | 2018-08-31 | 53FS-10d |  |  |  | 0d |  |  |
| 58 | 1.16 | SERRALHERIA | 30d | 2018-06-19 | 2018-07-30 | 54 |  |  |  | 24d |  |  |
| 59 | 1.17 | PINTURA | 75d | 2018-05-21 | 2018-08-31 | 55 | 2016-08-03 | 2016-08-03 | 1d | 0d |  |  |
| 60 | 1.18 | **PISOS** | 104d | 2018-04-10 | 2018-08-31 |  | 2016-08-03 | 2016-08-03 | 1d | 0d |  |  |
| 61 | 1.18.1 | CONTRAPISO | 55d | 2018-04-10 | 2018-06-25 | 53SS+10d | 2016-08-03 | 2016-08-03 | 1d | 0d |  | start no earlier than 2018-03-02 |
| 62 | 1.18.2 | PISOS EM PORCELANATOS | 60d | 2018-04-17 | 2018-07-09 | 61SS+5d | 2016-08-03 | 2016-08-03 | 1d | 4d | 0d |  |
| 63 | 1.18.3 | PISOS DE GRANILITE | 98d | 2018-04-11 | 2018-08-24 | 61SS+1d | 2016-08-03 | 2016-08-03 | 1d | 0d |  |  |
| 64 | 1.18.4 | PISO ELEVADO | 30d | 2018-04-11 | 2018-05-22 | 63SS | 2016-08-03 | 2016-08-03 | 1d | 73d |  |  |
| 65 | 1.18.5 | PISO TÁTIL | 5d | 2018-08-27 | 2018-08-31 | 63 | 2016-08-03 | 2016-08-03 | 1d | 0d |  |  |
| 66 | 1.18.6 | **RODAPÉS, SOLEIRAS E PEITORIS** | 51d | 2018-04-24 | 2018-07-03 |  | 2016-08-03 | 2016-08-03 | 1d | 43d |  |  |
| 67 | 1.18.6.1 | RODAPÉS | 30d | 2018-05-23 | 2018-07-03 | 63SS+30d | 2016-08-03 | 2016-08-03 | 1d | 43d |  |  |
| 68 | 1.18.6.2 | SOLEIRAS E PEITORIS | 30d | 2018-04-24 | 2018-06-04 | 62SS+5d | 2016-08-03 | 2016-08-03 | 1d | 64d |  |  |
| 69 | 1.19 | **APARELHOS E METAIS** | 76d | 2018-05-18 | 2018-08-31 |  | 2016-08-03 | 2016-08-03 | 1d | 0d |  |  |
| 70 | 1.19.1 | VÁLVULAS | 15d | 2018-07-23 | 2018-08-10 | 73 | 2016-08-03 | 2016-08-03 | 1d | 15d |  |  |
| 71 | 1.19.2 | TORNEIRAS | 30d | 2018-07-23 | 2018-08-31 | 73 | 2016-08-03 | 2016-08-03 | 1d | 0d |  |  |
| 72 | 1.19.3 | BACIAS SANITÁRIAS E ASSENTOS | 60d | 2018-05-18 | 2018-08-09 | 82FS+1d | 2016-08-03 | 2016-08-03 | 1d | 16d |  |  |
| 73 | 1.19.4 | LAVATÓRIOS | 46d | 2018-05-18 | 2018-07-20 | 82FS+1d | 2016-08-03 | 2016-08-03 | 1d | 0d |  |  |
| 74 | 1.19.5 | DISPENSER | 15d | 2018-07-24 | 2018-08-13 | 73FS+1d | 2016-08-03 | 2016-08-03 | 1d | 14d |  |  |
| 75 | 1.19.6 | ALARME | 10d | 2018-07-24 | 2018-08-06 | 73FS+1d | 2016-08-03 | 2016-08-03 | 1d | 19d |  |  |
| 76 | 1.19.7 | BARRA DE APOIO | 10d | 2018-07-24 | 2018-08-06 | 73FS+1d | 2016-08-03 | 2016-08-03 | 1d | 19d |  |  |
| 77 | 1.19.8 | DIVERSOS | 15d | 2018-07-24 | 2018-08-13 | 73FS+1d | 2016-08-03 | 2016-08-03 | 1d | 14d |  |  |
| 78 | 1.20 | BANCADAS | 60d | 2018-05-18 | 2018-08-09 | 73SS | 2016-08-03 | 2016-08-03 | 1d | 16d |  |  |
| 79 | 1.21 | ELEVADOR | 240d | 2017-03-24 | 2018-02-22 | 36SS+30d |  |  |  | 136d |  |  |

| ID | WBS | Task | Duration | Start | Finish | Predecessors | Baseline start | Baseline finish | Baseline duration | Total slack | Free slack |
| --- | --- | --- | --- | --- | --- | --- | --- | --- | --- | --- | --- |
| 80 | 1.22 | **INSTALAÇÕES HIDRÁULICAS E SANITÁRIAS** | 315d | 2017-03-23 | 2018-06-06 |  | 2016-08-03 | 2016-08-03 | 1d | 0d |  |
| 81 | 1.22.1 | REGISTROS | 30d | 2017-06-15 | 2017-07-26 | 82SS+60d | 2016-08-03 | 2016-08-03 | 1d | 287d |  |
| 82 | 1.22.2 | TUBOS E CONEXÕES DE ÁGUA FRIA | 300d | 2017-03-23 | 2018-05-16 | 83SS | 2016-08-03 | 2016-08-03 | 1d | 0d |  |
| 83 | 1.22.3 | TUBOS E CONEXÕES DE ESGOTO SANITÁRIO | 300d | 2017-03-23 | 2018-05-16 | 29FS+30d | 2016-08-03 | 2016-08-03 | 1d | 0d |  |
| 84 | 1.22.4 | TUBOS E CONEXÕES DE ÁGUAS PLUVIAIS | 100d | 2017-05-04 | 2017-09-20 | 83SS+30d | 2016-08-03 | 2016-08-03 | 1d | 216d | 0d |
| 85 | 1.22.5 | CAIXAS SIFONADAS E RALOS | 30d | 2017-09-22 | 2017-11-02 | 84FS+1d | 2016-08-03 | 2016-08-03 | 1d | 216d |  |
| 86 | 1.22.6 | RESERVATÓRIOS | 15d | 2018-05-17 | 2018-06-06 | 82 | 2016-08-03 | 2016-08-03 | 1d | 47d | 0d |
| 87 | 1.23 | **INSTALAÇÕES DE PROTEÇÃO E COMBATE A INCÊNDIO** | 147d | 2017-05-04 | 2017-11-24 |  | 2016-08-03 | 2016-08-03 | 1d | 200d |  |
| 88 | 1.23.1 | TUBO DE AÇO GALVANIZADO | 100d | 2017-05-04 | 2017-09-20 | 82SS+30d | 2016-08-03 | 2016-08-03 | 1d | 200d | 0d |
| 89 | 1.23.2 | HIDRANTE | 30d | 2017-09-22 | 2017-11-02 | 88FS+1d | 2016-08-03 | 2016-08-03 | 1d | 216d |  |
| 90 | 1.23.3 | EXTINTORES | 30d | 2017-09-22 | 2017-11-02 | 88FS+1d | 2016-08-03 | 2016-08-03 | 1d | 200d | 0d |
| 91 | 1.23.4 | PLACAS | 15d | 2017-11-06 | 2017-11-24 | 90FS+1d | 2016-08-03 | 2016-08-03 | 1d | 200d |  |
| 92 | 1.23.5 | ALARME DE INCÊNDIO | 30d | 2017-09-22 | 2017-11-02 | 88FS+1d | 2016-08-03 | 2016-08-03 | 1d | 216d |  |
| 93 | 1.23.6 | ILUMINAÇÃO DE EMERGÊNCIA | 30d | 2017-09-22 | 2017-11-02 | 88FS+1d | 2016-08-03 | 2016-08-03 | 1d | 216d |  |
| 94 | 1.23.7 | BOMBA | 15d | 2017-09-22 | 2017-10-12 | 88FS+1d | 2016-08-03 | 2016-08-03 | 1d | 231d |  |
| 95 | 1.24 | **INSTALAÇÕES ELÉTRICAS** | 377d | 2017-03-23 | 2018-08-31 |  | 2016-08-03 | 2016-08-03 | 1d | 0d |  |
| 96 | 1.24.1 | ELETRODUTOS E CONEXÕES | 250d | 2017-03-23 | 2018-03-07 | 29FS+30d | 2016-08-03 | 2016-08-03 | 1d | 0d |  |
| 97 | 1.24.2 | FIOS E CABOS | 60d | 2018-03-08 | 2018-05-30 | 96 | 2016-08-03 | 2016-08-03 | 1d | 0d |  |
| 98 | 1.24.3 | TOMADAS E INTERRUPTORES | 30d | 2018-05-31 | 2018-07-11 | 97 | 2016-08-03 | 2016-08-03 | 1d | 0d |  |
| 99 | 1.24.4 | CONDULETES E CAIXAS | 190d | 2017-03-23 | 2017-12-13 | 29FS+30d | 2016-08-03 | 2016-08-03 | 1d | 187d |  |
| 100 | 1.24.5 | ELETROCALHA E CONEXÕES | 190d | 2017-03-23 | 2017-12-13 | 96SS | 2016-08-03 | 2016-08-03 | 1d | 187d |  |
| 101 | 1.24.6 | LUMINÁRIAS | 67d | 2018-05-31 | 2018-08-31 | 98SS | 2016-08-03 | 2016-08-03 | 1d | 0d |  |
| 102 | 1.24.7 | QUADROS ELÉTRICOS | 60d | 2018-05-31 | 2018-08-22 | 98SS | 2016-08-03 | 2016-08-03 | 1d | 7d |  |
| 103 | 1.25 | **INSTALAÇÕES DE REDE LÓGICA E TELEFONIA** | 350d | 2017-03-23 | 2018-07-25 |  | 2016-08-03 | 2016-08-03 | 1d | 0d |  |
| 104 | 1.25.1 | ELETROCALHAS, ELETRODUTOS E CONEXÕES | 250d | 2017-03-23 | 2018-03-07 | 96SS | 2016-08-03 | 2016-08-03 | 1d | 0d |  |
| 105 | 1.25.2 | TOMADAS E CONECTORES | 200d | 2017-05-04 | 2018-02-07 | 104SS+30d | 2016-08-03 | 2016-08-03 | 1d | 0d |  |
| 106 | 1.25.3 | FIOS E CABOS PARA REDE LÓGICA | 120d | 2018-02-08 | 2018-07-25 | 105 | 2016-08-03 | 2016-08-03 | 1d | 0d |  |
| 107 | 1.25.4 | CONDULETES E CAIXAS | 200d | 2017-05-04 | 2018-02-07 | 105SS | 2016-08-03 | 2016-08-03 | 1d | 147d | 0d |
| 108 | 1.25.5 | RACK | 30d | 2017-06-15 | 2017-07-26 | 107SS+30d | 2016-08-03 | 2016-08-03 | 1d | 287d |  |

| ID | WBS | Task | Duration | Start | Finish | Predecessors | Baseline start | Baseline finish | Baseline duration | Total slack | Constraint |
| --- | --- | --- | --- | --- | --- | --- | --- | --- | --- | --- | --- |
| 109 | 1.26 | **SISTEMAS DE CFTV** | 147d | 2018-02-08 | 2018-08-31 |  | 2016-08-03 | 2016-08-03 | 1d | 0d |  |
| 110 | 1.26.1 | FIOS E CABOS PARA CFTV | 120d | 2018-02-08 | 2018-07-25 | 106SS | 2016-08-03 | 2016-08-03 | 1d | 0d |  |
| 111 | 1.26.2 | MONITORAMENTO E IMAGENS | 87d | 2018-05-03 | 2018-08-31 | 112SS+30d | 2016-08-03 | 2016-08-03 | 1d | 0d |  |
| 112 | 1.26.3 | FIBRA ÓPTICA | 60d | 2018-03-22 | 2018-06-13 | 110SS+30d | 2016-08-03 | 2016-08-03 | 1d | 0d |  |
| 113 | 1.27 | **INSTALAÇÕES DE SPDA** | 54d | 2018-06-19 | 2018-08-31 |  | 2016-08-03 | 2016-08-03 | 1d | 0d |  |
| 114 | 1.27.1 | CORDOALHAS | 54d | 2018-06-19 | 2018-08-31 | 54 | 2016-08-03 | 2016-08-03 | 1d | 0d |  |
| 115 | 1.27.2 | CAIXAS DE EQUALIZAÇÃO | 30d | 2018-06-19 | 2018-07-30 | 114SS | 2016-08-03 | 2016-08-03 | 1d | 24d |  |
| 116 | 1.27.3 | CONECTORES, PARAFUSOS, PRESILHAS E VEDAÇÕES | 49d | 2018-06-26 | 2018-08-31 | 114SS+5d | 2016-08-03 | 2016-08-03 | 1d | 0d |  |
| 117 | 1.28 | INSTALAÇÕES DE GASES | 60d | 2017-07-21 | 2017-10-12 |  | 2016-08-03 | 2016-08-03 | 1d | 231d | start no earlier than 2017-07-21 |
| 118 | 1.29 | **INSTALAÇÕES DE AR-CONDICIONADO** | 270d | 2017-03-23 | 2018-04-04 |  | 2016-08-03 | 2016-08-03 | 1d | 0d |  |
| 119 | 1.29.1 | UNIDADES CLIMATIZADORAS | 90d | 2017-11-30 | 2018-04-04 | 126SS | 2016-08-03 | 2016-08-03 | 1d | 0d |  |
| 120 | 1.29.2 | ACESSÓRIOS PARA CAPTAÇÃO E INSUFLAMENTO DE AR | 90d | 2017-11-30 | 2018-04-04 | 119SS | 2016-08-03 | 2016-08-03 | 1d | 0d |  |
| 121 | 1.29.3 | REDES DE DUTOS | 120d | 2017-03-23 | 2017-09-06 | 96SS | 2016-08-03 | 2016-08-03 | 1d | 0d |  |
| 122 | 1.29.4 | DUTOS FLEXÍVEIS | 120d | 2017-03-23 | 2017-09-06 | 121SS | 2016-08-03 | 2016-08-03 | 1d | 150d |  |
| 123 | 1.29.5 | INSTALAÇÃO ELÉTRICA | 120d | 2017-05-04 | 2017-10-18 | 121SS+30d | 2016-08-03 | 2016-08-03 | 1d | 0d |  |
| 124 | 1.29.6 | CABOS | 90d | 2017-10-19 | 2018-02-21 | 123 | 2016-08-03 | 2016-08-03 | 1d | 0d |  |
| 125 | 1.29.7 | ELETRODUTOS | 90d | 2017-03-23 | 2017-07-26 | 121SS | 2016-08-03 | 2016-08-03 | 1d | 180d |  |
| 126 | 1.29.8 | INTERLIGAÇÃO FRIGORÍFICA | 90d | 2017-11-30 | 2018-04-04 | 124SS+30d | 2016-08-03 | 2016-08-03 | 1d | 0d |  |
| 127 | 1.30 | SINALIZAÇÃO VISUAL | 15d | 2018-08-13 | 2018-08-31 | 59FS-15d |  |  |  | 0d |  |
| 128 | 1.31 | **SERVIÇOS DE PAISAGISMO** | 45d | 2018-07-02 | 2018-08-31 |  | 2016-08-03 | 2016-08-03 | 1d | 0d |  |
| 129 | 1.31.1 | PAISAGISMO INTERNO | 30d | 2018-07-02 | 2018-08-10 |  |  |  |  | 0d | start no earlier than 2018-07-02 |
| 130 | 1.31.2 | PAISAGISMO EXTERNO | 45d | 2018-07-02 | 2018-08-31 | 129SS |  |  |  | 0d |  |
| 131 | 1.32 | **LIMPEZA DE OBRA TOTAL** | 514d | 2016-09-08 | 2018-08-31 |  | 2016-08-03 | 2016-08-03 | 1d | 0d |  |
| 132 | 1.32.1 | LIMPEZA PERMANENTE DA OBRA | 474d | 2016-09-08 | 2018-07-06 | 20SS+10d | 2016-08-03 | 2016-08-03 | 1d | 0d |  |
| 133 | 1.32.2 | LIMPEZA FINAL PARA ENTREGA DA OBRA | 40d | 2018-07-09 | 2018-08-31 | 132 | 2016-08-03 | 2016-08-03 | 1d | 0d |  |
